# Habilitación cobertizo

Schedule from MS Project, 2015-03-10 to 2015-03-17, 7 hours a day.
ENI

## Calendars

- Standard: Mon-Fri 09:00-13:00, 15:00-19:00; Sat-Sun off.

## Resources

| Resource | Group |
| --- | --- |
| CHEVERT | CA |
| LAVOISIER | CA |
| ORLANDO | MA |
| DA SILVA | MA |
| ROUVIERE | MA |
| MARTINEZ | MA |
| LE BRAZ | ME |
| LITTIOU | ME |
| MARIN | ME |
| DERRIEN | PL |
| SAULNIER | PL |

## Schedule

| ID | WBS | Task | Type | Duration | Start | Finish | Predecessors | Total slack | Free slack | Resources | Work |
| --- | --- | --- | --- | --- | --- | --- | --- | --- | --- | --- | --- |
| 1 | 1 | **Albañilería** |  | 1.5d | 2015-03-10 | 2015-03-11 |  | 0d |  |  | 23.62h |
| 2 | 1.1 | Construcción muro exterior |  | 1d | 2015-03-10 | 2015-03-10 |  | 0d |  | ORLANDO; MARTINEZ | 14h |
| 3 | 1.2 | Revestimiento |  | 0.5d | 2015-03-11 | 2015-03-11 | 2 | 3.75d | 1.5d | DA SILVA [75%] | 2.62h |
| 4 | 1.3 | Apertura de puertas |  | 1d | 2015-03-10 | 2015-03-10 |  | 2d | 0d | ROUVIERE | 7h |
| 5 | 2 | **Carpintería** |  | 2.75d | 2015-03-11 | 2015-03-13 |  | 0d |  |  | 31.5h |
| 6 | 2.1 | Aislamiento del techo |  | 1d | 2015-03-11 | 2015-03-11 | 2 | 0d |  | MARIN | 7h |
| 7 | 2.2 | Colocación revestimiento |  | 1d | 2015-03-12 | 2015-03-12 | 6 | 0d |  | MARIN | 7h |
| 8 | 2.3 | Colocación del vano |  | 0.75d | 2015-03-13 | 2015-03-13 | 3, 7 | 2.25d |  | LE BRAZ; LITTIOU | 10.5h |
| 9 | 2.4 | Colocación puertas |  | 0.5d | 2015-03-11 | 2015-03-11 | 4 | 3.5d | 0d | LE BRAZ; LITTIOU | 7h |
| 10 | 3 | **Escayolas** |  | 4.5d | 2015-03-11 | 2015-03-17 |  | 0d |  |  | 42h |
| 11 | 3.1 | Colocación placas |  | 3d | 2015-03-13 | 2015-03-17 | 4, 7, 14 | 0d |  | DERRIEN; SAULNIER | 42h |
| 12 | 3.2 | Empalme puertas |  | 1d | 2015-03-11 | 2015-03-12 | 9 | 3.5d |  |  |  |
| 13 | 4 | **Embaldosado** |  | 5.33d | 2015-03-10 | 2015-03-17 |  | 0d |  |  | 21h |
| 14 | 4.1 | **Losa de cemento** |  | 2d | 2015-03-10 | 2015-03-11 |  | 0d |  |  | 14h |
| 15 | 4.1.1 | 1ère couche |  | 1d | 2015-03-10 | 2015-03-10 |  | 0d |  | CHEVERT | 7h |
| 16 | 4.1.2 | 2ème couche |  | 1d | 2015-03-11 | 2015-03-11 | 15FS+12eh | 0.67d | 0d | CHEVERT | 7h |
| 17 | 4.2 | Colocación del baldosas |  | 3.33d | 2015-03-12 | 2015-03-17 | 16 | 0.67d | 0d | LAVOISIER [50%] | 7h |
| 18 | 5 | Terminación estancia | milestone | 0d | 2015-03-17 | 2015-03-17 | 17 | 0.67d |  |  |  |
